# پروژه تقاطع غيرهمسطح

Schedule from MS Project, 2014-02-16 to 2015-09-04, status date 2014-02-16, A marks actual dates.
Ariana

## Calendars

- Standard: Mon-Sun 08:00-16:00.

## Schedule

| ID | WBS | Task | Type | Duration | Start | Finish | Predecessors | Complete | Baseline start | Baseline finish | Baseline duration | Text10 | Text11 | Text27 | Text29 | Text30 |
| --- | --- | --- | --- | --- | --- | --- | --- | --- | --- | --- | --- | --- | --- | --- | --- | --- |
| 1 | 1 | **رويدادهاي کليدي** |  | 5d | 2014-02-16 A | 2014-02-20 A |  | 100% | 2014-02-16 | 2014-02-20 | 5d | 92/11/27 | 92/12/1 | 92/11/27 | 92/11/27 | 92/12/1 |
| 2 | 1 | تحویل زمین |  | 1d | 2014-02-20 A | 2014-02-20 A | 4FS+5d | 100% | 2014-02-20 | 2014-02-20 | 0d | 92/12/1 | 92/12/1 | 92/12/1 | 92/12/1 | 92/12/1 |
| 3 | 1 | تحویل زمین تجهیز کارگاه |  | 1d | 2014-02-16 A | 2014-02-16 A | 4 | 100% | 2014-02-16 | 2014-02-16 | 0d | 92/11/27 | 92/11/27 | 92/11/27 | 92/11/27 | 92/11/27 |
| 4 | 1 | شروع پروژه |  | 1d | 2014-02-16 A | 2014-02-16 A |  | 100% | 2014-02-16 | 2014-02-16 | 0d | 92/11/27 | 92/11/27 | 92/11/27 | 92/11/27 | 92/11/27 |
| 5 | 2 | **تجهيز کارگاه** |  | 449d | 2014-02-21 A | 2015-05-15 A |  | 100% | 2014-02-21 | 2014-09-30 | 222d | 92/12/2 | 93/7/8 | 92/12/2 | 92/12/2 | 94/2/25 |
| 6 | 2 | تجهيز کارگاه اصلي |  | 7d | 2014-02-21 A | 2014-02-27 A | 3FS+5d | 100% | 2014-02-21 | 2014-02-27 | 7d | 92/12/2 | 92/12/8 | 92/12/2 | 92/12/2 | 92/12/8 |
| 7 | 2 | تجهيز کارگاه موقت ضلع شرقي رمپ ورودي طبق انحراف ترافيک مرحله اول عمليات |  | 7d | 2014-03-01 A | 2014-03-07 A | 15, 2 | 100% | 2014-03-01 | 2014-03-07 | 7d | 92/12/10 | 92/12/16 | 92/12/10 | 92/12/10 | 92/12/16 |
| 8 | 2 | تجهيز کارگاه موقت ضلع جنوبي رمپ خروجي طبق انحراف ترافيک مرحله اول عمليات اجرا |  | 7d | 2014-03-01 A | 2014-03-07 A | 15, 2 | 100% | 2014-03-01 | 2014-03-07 | 7d | 92/12/10 | 92/12/16 | 92/12/10 | 92/12/10 | 92/12/16 |
| 9 | 2 | تجهیز کارگاه موقت طبق انحراف ترافیک مرحله دوم عملیات اجرا |  | 3d | 2015-04-05 A | 2015-04-07 A | 15, 2, 101 | 100% | 2014-05-07 | 2014-05-09 | 3d | 93/2/17 | 93/2/19 | 94/1/16 | 94/1/16 | 94/1/18 |
| 10 | 2.5 | تجهیز کارگاه موقت طبق انحراف ترافیک مرحله سوم عملیات اجرا |  | 3d | 2015-05-13 A | 2015-05-15 A | 2, 15, 128 | 100% | 2014-06-20 | 2014-06-22 | 3d | 93/3/30 | 93/4/1 | 94/2/23 | 94/2/23 | 94/2/25 |
| 11 | 2.6 | تجهیز کارگاه موقت طبق انحراف ترافیک مرحله چهارم عملیات اجرا |  | 3d | 2014-10-18 A | 2014-10-20 A | 2, 15, 142 | 100% | 2014-08-13 | 2014-08-15 | 3d | 93/5/22 | 93/5/24 | 93/7/26 | 93/7/26 | 93/7/28 |
| 12 | 2 | تجهیز کارگاه موقت طبق انحراف ترافیک مرحله پنجم عملیات اجرا |  | 3d | 2015-04-10 A | 2015-04-12 A | 2, 15, 175 | 100% | 2014-09-28 | 2014-09-30 | 3d | 93/7/6 | 93/7/8 | 94/1/21 | 94/1/21 | 94/1/23 |
| 13 | 3 | **مجوزها** |  | 350d | 2014-02-16 A | 2015-02-01 A |  | 100% | 2014-02-16 | 2014-03-01 | 14d | 92/11/27 | 92/12/10 | 92/11/27 | 92/11/27 | 93/11/12 |
| 14 | 3 | ابلاغ مجوز حفاري |  | 1d | 2014-02-16 A | 2014-02-16 A | 4 | 100% | 2014-02-16 | 2014-02-16 | 0d | 92/11/27 | 92/11/27 | 92/11/27 | 92/11/27 | 92/11/27 |
| 15 | 3 | ابلاغ مجوز راهنمايي و رانندگي |  | 1d | 2014-03-01 A | 2014-03-01 A | 4FS+13d | 100% | 2014-02-28 | 2014-02-28 | 0d | 92/12/9 | 92/12/9 | 92/12/10 | 92/12/10 | 92/12/10 |
| 16 | 3.1 | **مجوزهاي رفع معارضات** |  | 350d | 2014-02-16 A | 2015-02-01 A |  | 100% | 2014-02-16 | 2014-03-01 | 14d | 92/11/27 | 92/12/10 | 92/11/27 | 92/11/27 | 93/11/12 |
| 17 | 3.1 | ابلاغ طرح جديد و مجوز برچيدن معارضات لوله هاي گازرساني از اداره گاز | milestone | 0d | 2014-08-03 A | 2014-08-03 A | 4, 24 | 100% | 2014-02-28 | 2014-02-28 | 0d | 92/12/9 | 92/12/9 | 93/5/12 | 93/5/12 | 93/5/12 |
| 18 | 3.1 | ابلاغ طرح جديد و مجوز برچيدن معارضات لوله هاي آب و فاضلاب از سازمان آبفا | milestone | 0d | 2014-05-05 A | 2014-05-05 A | 4, 24 | 100% | 2014-02-28 | 2014-02-28 | 0d | 92/12/9 | 92/12/9 | 93/2/15 | 93/2/15 | 93/2/15 |
| 19 | 3.1 | ابلاغ طرح جديد و مجوز برچيدن معارضات برقي از اداره برق | milestone | 0d | 2015-02-01 A | 2015-02-01 A | 4, 24 | 100% | 2014-02-28 | 2014-02-28 | 0d | 92/12/9 | 92/12/9 | 93/11/12 | 93/11/12 | 93/11/12 |
| 20 | 3.1 | ابلاغ مجوز برچیدن معارضات اشجاری و لوله های انتقال آب از سازمان فضای سبز و پارکها | milestone | 0d | 2014-12-10 A | 2014-12-10 A | 4, 24 | 100% | 2014-02-28 | 2014-02-28 | 0d | 92/12/9 | 92/12/9 | 93/9/19 | 93/9/19 | 93/9/19 |
| 21 | 3.3.5 | ابلاغ مجوز برچيدن تابلوهاي راهنمايي و رانندگي | milestone | 0d | 2014-03-01 A | 2014-03-01 A | 4, 24 | 100% | 2014-03-01 | 2014-03-01 | 0d | 92/12/10 | 92/12/10 | 92/12/10 | 92/12/10 | 92/12/10 |
| 22 | 3.3.6 | ابلاغ طرح جدید و مجوز برچیدن کانالهای آبهای سطحی و زیر زمینی از شهرداری | milestone | 0d | 2014-03-01 A | 2014-03-01 A | 4, 24 | 100% | 2014-03-01 | 2014-03-01 | 0d | 92/12/10 | 92/12/10 | 92/12/10 | 92/12/10 | 92/12/10 |
| 23 | 3.3.7 | ابلاغ مجوز و برچیدن تابلوهای تبلیغاتی | milestone | 0d | 2014-02-16 A | 2014-02-16 A | 4 | 100% | 2014-02-16 | 2014-02-16 | 0d | 92/11/27 | 92/11/27 | 92/11/27 | 92/11/27 | 92/11/27 |
| 24 | 3.1 | سونداژ و شناسایی معارضات | milestone | 0d | 2014-02-28 A | 2014-02-28 A | 14, 15 | 100% | 2014-02-28 | 2014-02-28 | 0d | 92/12/9 | 92/12/9 | 92/12/9 | 92/12/9 | 92/12/9 |
| 25 | 3.3.9 | ابلاغ طرح جدید کابلهای مخابرات | milestone | 0d | 2014-07-12 A | 2014-07-12 A | 24 | 100% | 2014-03-01 | 2014-03-01 | 0d | 92/12/10 | 92/12/10 | 93/4/21 | 93/4/21 | 93/4/21 |

| ID | WBS | Task | Duration | Start | Finish | Predecessors | Complete | Baseline start | Baseline finish | Baseline duration | Text10 | Text11 | Text27 | Text29 | Text30 |
| --- | --- | --- | --- | --- | --- | --- | --- | --- | --- | --- | --- | --- | --- | --- | --- |
| 26 | 4 | **مرحله اول عمليات اجرايي** | 413d | 2014-02-16 A | 2015-04-04 A |  | 100% | 2014-02-17 | 2014-05-18 | 91d | 92/11/28 | 93/2/28 | 92/11/27 | 92/11/27 | 94/1/15 |
| 27 | 4.13 | **جايگزيني معارضات** | 370d | 2014-02-16 A | 2015-02-20 A |  | 100% | 2014-02-17 | 2014-04-14 | 57d | 92/11/28 | 93/1/25 | 92/11/27 | 92/11/27 | 93/12/1 |
| 28 | 4.13 | برچیدن و احداث طرح جدید معارضات لوله های گازرسانی | 45d | 2014-08-03 A | 2014-09-16 A | 17 | 100% | 2014-03-01 | 2014-04-14 | 45d | 92/12/10 | 93/1/25 | 93/5/12 | 93/5/12 | 93/6/25 |
| 29 | 4.1.2 | برچیدن و احداث طرح جدید معارضات لوله های آب و فاضلاب | 45d | 2014-05-05 A | 2014-06-18 A | 18 | 100% | 2014-03-01 | 2014-04-14 | 45d | 92/12/10 | 93/1/25 | 93/2/15 | 93/2/15 | 93/3/28 |
| 30 | 4.1.3 | برچیدن و احداث طرح جدید معارضات برقی | 20d | 2015-02-01 A | 2015-02-20 A | 19 | 100% | 2014-03-01 | 2014-03-20 | 20d | 92/12/10 | 92/12/29 | 93/11/12 | 93/11/12 | 93/12/1 |
| 31 | 4.1.4 | برچیدن و احداث طرح جدید معارضات اشجاری و لوله های انتقال آب | 20d | 2014-12-10 A | 2014-12-29 A | 20 | 100% | 2014-03-01 | 2014-03-20 | 20d | 92/12/10 | 92/12/29 | 93/9/19 | 93/9/19 | 93/10/8 |
| 32 | 4.1.5 | برچیدن و احداث طرح جدید تابلوهای راهنمایی و رانندگی | 19d | 2014-03-01 A | 2014-03-19 A | 21 | 100% | 2014-03-02 | 2014-03-20 | 19d | 92/12/11 | 92/12/29 | 92/12/10 | 92/12/10 | 92/12/28 |
| 33 | 4.1.6 | برچیدن و احداث طرح جدید کانالهای آبهای سطحی و زیر زمینی | 44d | 2014-03-01 A | 2014-04-13 A | 22 | 100% | 2014-03-02 | 2014-04-14 | 44d | 92/12/11 | 93/1/25 | 92/12/10 | 92/12/10 | 93/1/24 |
| 34 | 4.1.7 | برچیدن تابلوهای تبلیغاتی | 30d | 2014-02-16 A | 2014-03-17 A | 23 | 100% | 2014-02-17 | 2014-03-18 | 30d | 92/11/28 | 92/12/27 | 92/11/27 | 92/11/27 | 92/12/26 |
| 35 | 4.13 | برچیدن و احداث طرح جدید کابل های مخابرات | 20d | 2014-07-12 A | 2014-07-31 A | 25 | 100% | 2014-03-02 | 2014-03-21 | 20d | 92/12/11 | 93/1/1 | 93/4/21 | 93/4/21 | 93/5/9 |
| 36 | 4.1 | **اجراي شمعهاي محور شرقي رمپ ورودي** | 95d | 2014-03-08 A | 2014-06-10 A |  | 100% | 2014-03-08 | 2014-04-23 | 47d | 92/12/17 | 93/2/3 | 92/12/17 | 92/12/17 | 93/3/20 |
| 37 | 4.1.1 | حفاری شمع | 60d | 2014-03-21 A | 2014-05-19 A | 31, 32, 7, 30, 34 | 100% | 2014-03-21 | 2014-04-19 | 30d | 93/1/1 | 93/1/30 | 93/1/1 | 93/1/1 | 93/2/29 |
| 38 | 4.2.2 | آرماتوربندی شمع | 60d | 2014-03-08 A | 2014-05-06 A | 6FS+8d | 100% | 2014-03-08 | 2014-04-06 | 30d | 92/12/17 | 93/1/17 | 92/12/17 | 92/12/17 | 93/2/16 |
| 39 | 4.2.3 | کیج گذاری شمع | 68d | 2014-04-02 A | 2014-06-08 A | 37FS-18d, 38FS-18d | 100% | 2014-04-02 | 2014-04-21 | 20d | 93/1/13 | 93/2/1 | 93/1/13 | 93/1/13 | 93/3/18 |
| 40 | 4.2.4 | بتن ریزی شمع ها | 68d | 2014-04-04 A | 2014-06-10 A | 39FS-18d | 100% | 2014-04-04 | 2014-04-23 | 20d | 93/1/15 | 93/2/3 | 93/1/15 | 93/1/15 | 93/3/20 |
| 41 | 4.2 | **اجراي تير همبند محور شرقي رمپ ورودي** | 25d | 2014-06-11 A | 2014-07-05 A |  | 100% | 2014-04-24 | 2014-05-18 | 25d | 93/2/4 | 93/2/28 | 93/3/21 | 93/3/21 | 93/4/14 |
| 42 | 4.2 | آرماتور بندي | 10d | 2014-06-11 A | 2014-06-20 A | 40 | 100% | 2014-04-24 | 2014-05-03 | 10d | 93/2/4 | 93/2/13 | 93/3/21 | 93/3/21 | 93/3/30 |
| 43 | 4.2 | قالب بندي | 10d | 2014-06-21 A | 2014-06-30 A | 42 | 100% | 2014-05-04 | 2014-05-13 | 10d | 93/2/14 | 93/2/23 | 93/3/31 | 93/3/31 | 93/4/9 |
| 44 | 4.2 | بتن ريزي | 5d | 2014-07-01 A | 2014-07-05 A | 43 | 100% | 2014-05-14 | 2014-05-18 | 5d | 93/2/24 | 93/2/28 | 93/4/10 | 93/4/10 | 93/4/14 |
| 45 | 4.3 | **اجرای شمعهای ضلع جنوبی رمپ خروجی** | 93d | 2014-03-08 A | 2014-06-08 A |  | 100% | 2014-03-08 | 2014-04-10 | 34d | 92/12/17 | 93/1/21 | 92/12/17 | 92/12/17 | 93/3/18 |
| 46 | 4.3.1 | حفاری شمع ها | 81d | 2014-03-08 A | 2014-05-27 A | 8, 19, 20, 21, 23 | 100% | 2014-03-08 | 2014-04-06 | 30d | 92/12/17 | 93/1/17 | 92/12/17 | 92/12/17 | 93/3/6 |
| 47 | 4.3.1 | آرماتوربندی شمع | 81d | 2014-03-08 A | 2014-05-27 A | 6FS+8d | 100% | 2014-03-08 | 2014-04-06 | 30d | 92/12/17 | 93/1/17 | 92/12/17 | 92/12/17 | 93/3/6 |
| 48 | 4.3.2 | کیج گذاری | 80d | 2014-03-20 A | 2014-06-07 A | 46FS-18d, 47FS-18d | 100% | 2014-03-20 | 2014-04-08 | 20d | 92/12/29 | 93/1/19 | 92/12/29 | 92/12/29 | 93/3/17 |
| 49 | 4.3.2 | بتن ریزی شمع ها | 79d | 2014-03-22 A | 2014-06-08 A | 48FS-18d | 100% | 2014-03-22 | 2014-04-10 | 20d | 93/1/2 | 93/1/21 | 93/1/2 | 93/1/2 | 93/3/18 |

| ID | WBS | Task | Duration | Start | Finish | Predecessors | Complete | Baseline start | Baseline finish | Baseline duration | Text10 | Text11 | Text27 | Text29 | Text30 |
| --- | --- | --- | --- | --- | --- | --- | --- | --- | --- | --- | --- | --- | --- | --- | --- |
| 50 | 4.4 | **اجرای تیرهمبند ضلع جنوبی رمپ خروجی** | 25d | 2014-06-09 A | 2014-07-03 A |  | 100% | 2014-04-11 | 2014-05-05 | 25d | 93/1/22 | 93/2/15 | 93/3/19 | 93/3/19 | 93/4/12 |
| 51 | 4.4 | آرماتور بندي | 10d | 2014-06-09 A | 2014-06-18 A | 49 | 100% | 2014-04-11 | 2014-04-20 | 10d | 93/1/22 | 93/1/31 | 93/3/19 | 93/3/19 | 93/3/28 |
| 52 | 4.4 | قالب بندي | 10d | 2014-06-19 A | 2014-06-28 A | 51 | 100% | 2014-04-21 | 2014-04-30 | 10d | 93/2/1 | 93/2/10 | 93/3/29 | 93/3/29 | 93/4/7 |
| 53 | 4.4 | بتن ريزي | 5d | 2014-06-29 A | 2014-07-03 A | 52 | 100% | 2014-05-01 | 2014-05-05 | 5d | 93/2/11 | 93/2/15 | 93/4/8 | 93/4/8 | 93/4/12 |
| 54 | 4.5 | **اجراي فونداسيون و ديوارهاي حائل ضلع جنوبی رمپ خروجی** | 114d | 2014-03-22 A | 2014-07-13 A |  | 100% | 2014-03-22 | 2014-05-03 | 43d | 93/1/2 | 93/2/13 | 93/1/2 | 93/1/2 | 93/4/22 |
| 55 | 4.5 | خاکبرداري محل ديوار و فونداسيون | 36d | 2014-03-22 A | 2014-04-26 A | 8, 31FS+1d, 32FS+1d, 30FS+1d | 100% | 2014-03-22 | 2014-03-31 | 10d | 93/1/2 | 93/1/11 | 93/1/2 | 93/1/2 | 93/2/6 |
| 56 | 4.5 | اجراي بتن مگر | 18d | 2014-04-01 A | 2014-04-18 A | 55 | 100% | 2014-04-01 | 2014-04-02 | 2d | 93/1/12 | 93/1/13 | 93/1/12 | 93/1/12 | 93/1/29 |
| 57 | 4.5 | آرماتوربندي فونداسيون | 22d | 2014-04-03 A | 2014-04-24 A | 56 | 100% | 2014-04-03 | 2014-04-07 | 5d | 93/1/14 | 93/1/18 | 93/1/14 | 93/1/14 | 93/2/4 |
| 58 | 4.5 | قالب بندي فونداسيون | 22d | 2014-04-08 A | 2014-04-29 A | 57 | 100% | 2014-04-08 | 2014-04-12 | 5d | 93/1/19 | 93/1/23 | 93/1/19 | 93/1/19 | 93/2/9 |
| 59 | 4.5 | بتن ريزي فونداسيون | 10d | 2014-04-13 A | 2014-04-22 A | 58 | 100% | 2014-04-13 | 2014-04-14 | 2d | 93/1/24 | 93/1/25 | 93/1/24 | 93/1/24 | 93/2/2 |
| 60 | 4.5 | آرماتوربندي ديوار حائل | 20d | 2014-04-15 A | 2014-05-04 A | 59 | 100% | 2014-04-15 | 2014-04-19 | 5d | 93/1/26 | 93/1/30 | 93/1/26 | 93/1/26 | 93/2/14 |
| 61 | 4.5 | قالب بندي ديوار حائل | 60d | 2014-04-20 A | 2014-06-18 A | 60 | 100% | 2014-04-20 | 2014-04-29 | 10d | 93/1/31 | 93/2/9 | 93/1/31 | 93/1/31 | 93/3/28 |
| 62 | 4.5 | بتن ريزي ديوار حائل | 64d | 2014-04-30 A | 2014-07-02 A | 61 | 100% | 2014-04-30 | 2014-05-01 | 2d | 93/2/10 | 93/2/11 | 93/2/10 | 93/2/10 | 93/4/11 |
| 63 | 4.5 | اجراي درناژ پشت ديوار | 73d | 2014-05-02 A | 2014-07-13 A | 62 | 100% | 2014-05-02 | 2014-05-03 | 2d | 93/2/12 | 93/2/13 | 93/2/12 | 93/2/12 | 93/4/22 |
| 64 | 4.6 | **اجراي فونداسيون و ديوارهاي حائل ضلع شرقي رمپ ورودي** | 43d | 2014-03-08 A | 2014-04-19 A |  | 100% | 2014-03-08 | 2014-04-19 | 43d | 92/12/17 | 93/1/30 | 92/12/17 | 92/12/17 | 93/1/30 |
| 65 | 4.6 | خاکبرداري محل ديوار و فونداسيون | 10d | 2014-03-08 A | 2014-03-17 A | 7, 21FS+1d | 100% | 2014-03-08 | 2014-03-17 | 10d | 92/12/17 | 92/12/26 | 92/12/17 | 92/12/17 | 92/12/26 |
| 66 | 4.6 | اجراي بتن مگر | 2d | 2014-03-18 A | 2014-03-19 A | 65 | 100% | 2014-03-18 | 2014-03-19 | 2d | 92/12/27 | 92/12/28 | 92/12/27 | 92/12/27 | 92/12/28 |
| 67 | 4.6 | آرماتوربندي فونداسيون | 5d | 2014-03-20 A | 2014-03-24 A | 66 | 100% | 2014-03-20 | 2014-03-24 | 5d | 92/12/29 | 93/1/4 | 92/12/29 | 92/12/29 | 93/1/4 |
| 68 | 4.6 | قالب بندي فونداسيون | 5d | 2014-03-25 A | 2014-03-29 A | 67 | 100% | 2014-03-25 | 2014-03-29 | 5d | 93/1/5 | 93/1/9 | 93/1/5 | 93/1/5 | 93/1/9 |
| 69 | 4.6 | بتن ريزي فونداسيون | 2d | 2014-03-30 A | 2014-03-31 A | 68 | 100% | 2014-03-30 | 2014-03-31 | 2d | 93/1/10 | 93/1/11 | 93/1/10 | 93/1/10 | 93/1/11 |
| 70 | 4.6 | آرماتوربندي ديوار حائل | 5d | 2014-04-01 A | 2014-04-05 A | 69 | 100% | 2014-04-01 | 2014-04-05 | 5d | 93/1/12 | 93/1/16 | 93/1/12 | 93/1/12 | 93/1/16 |
| 71 | 4.6 | قالب بندي ديوار حائل | 10d | 2014-04-06 A | 2014-04-15 A | 70 | 100% | 2014-04-06 | 2014-04-15 | 10d | 93/1/17 | 93/1/26 | 93/1/17 | 93/1/17 | 93/1/26 |
| 72 | 4.6 | بتن ريزي ديوار حائل | 2d | 2014-04-16 A | 2014-04-17 A | 71 | 100% | 2014-04-16 | 2014-04-17 | 2d | 93/1/27 | 93/1/28 | 93/1/27 | 93/1/27 | 93/1/28 |
| 73 | 4.6 | اجراي درناژ پشت ديوار | 2d | 2014-04-18 A | 2014-04-19 A | 72 | 100% | 2014-04-18 | 2014-04-19 | 2d | 93/1/29 | 93/1/30 | 93/1/29 | 93/1/29 | 93/1/30 |

| ID | WBS | Task | Duration | Start | Finish | Predecessors | Complete | Baseline start | Baseline finish | Baseline duration | Text10 | Text11 | Text27 | Text29 | Text30 |
| --- | --- | --- | --- | --- | --- | --- | --- | --- | --- | --- | --- | --- | --- | --- | --- |
| 74 | 4.7 | **اجراي پياده رو و جداول خيابان ضلع شرقي رمپ ورودي** | 30d | 2014-12-30 A | 2015-01-28 A |  | 100% | 2014-03-21 | 2014-04-19 | 30d | 93/1/1 | 93/1/30 | 93/10/9 | 93/10/9 | 93/11/8 |
| 75 | 4.7 | تخريب جداول قديمي | 20d | 2014-12-30 A | 2015-01-18 A | 7, 31 | 100% | 2014-03-21 | 2014-04-09 | 20d | 93/1/1 | 93/1/20 | 93/10/9 | 93/10/9 | 93/10/28 |
| 76 | 4.7 | تخريب پياده رو قديمي | 20d | 2014-12-31 A | 2015-01-19 A | 7, 75FS-19d | 100% | 2014-03-22 | 2014-04-10 | 20d | 93/1/2 | 93/1/21 | 93/10/10 | 93/10/10 | 93/10/29 |
| 77 | 4.7 | احداث جداول | 20d | 2015-01-04 A | 2015-01-23 A | 75FS-15d | 100% | 2014-03-26 | 2014-04-14 | 20d | 93/1/6 | 93/1/25 | 93/10/14 | 93/10/14 | 93/11/3 |
| 78 | 4.7 | احداث پياده رو | 20d | 2015-01-09 A | 2015-01-28 A | 77FS-15d | 100% | 2014-03-31 | 2014-04-19 | 20d | 93/1/11 | 93/1/30 | 93/10/19 | 93/10/19 | 93/11/8 |
| 79 | 4.8 | **اجراي پياده رو و جداول قسمت شمالی محور شرقی غربی** | 31d | 2015-02-21 A | 2015-03-23 A |  | 100% | 2014-03-21 | 2014-04-20 | 31d | 93/1/1 | 93/1/31 | 93/12/2 | 93/12/2 | 94/1/3 |
| 80 | 4.8 | تخريب جداول قديمي | 20d | 2015-02-21 A | 2015-03-12 A | 31, 32, 6, 30 | 100% | 2014-03-21 | 2014-04-09 | 20d | 93/1/1 | 93/1/20 | 93/12/2 | 93/12/2 | 93/12/21 |
| 81 | 4.8 | تخريب پياده رو قديمي | 20d | 2015-02-22 A | 2015-03-13 A | 80FS-19d | 100% | 2014-03-22 | 2014-04-10 | 20d | 93/1/2 | 93/1/21 | 93/12/3 | 93/12/3 | 93/12/22 |
| 82 | 4.8 | احداث جداول | 20d | 2015-02-27 A | 2015-03-18 A | 81FS-15d | 100% | 2014-03-27 | 2014-04-15 | 20d | 93/1/7 | 93/1/26 | 93/12/8 | 93/12/8 | 93/12/27 |
| 83 | 4.8 | احداث پياده رو | 20d | 2015-03-04 A | 2015-03-23 A | 82FS-15d | 100% | 2014-04-01 | 2014-04-20 | 20d | 93/1/12 | 93/1/31 | 93/12/13 | 93/12/13 | 94/1/3 |
| 84 | 4.9 | **اجراي پياده رو و جداول قسمت شرقی و غربی و رفوژ میانی محور جنوب به شمال بعد از سه راه کاج** | 379d | 2014-03-20 A | 2015-04-02 A |  | 100% | 2014-03-21 | 2014-04-30 | 41d | 93/1/1 | 93/2/10 | 92/12/29 | 92/12/29 | 94/1/13 |
| 85 | 4.9 | تخريب جداول قديمي | 20d | 2015-02-21 A | 2015-03-12 A | 6, 31, 30 | 100% | 2014-03-21 | 2014-04-09 | 20d | 93/1/1 | 93/1/20 | 93/12/2 | 93/12/2 | 93/12/21 |
| 86 | 4.9 | تخريب پياده رو قديمي | 20d | 2015-02-22 A | 2015-03-13 A | 85FS-19d | 100% | 2014-03-22 | 2014-04-10 | 20d | 93/1/2 | 93/1/21 | 93/12/3 | 93/12/3 | 93/12/22 |
| 87 | 4.9 | احداث جداول | 20d | 2015-03-04 A | 2015-03-23 A | 86FS-10d | 100% | 2014-04-01 | 2014-04-20 | 20d | 93/1/12 | 93/1/31 | 93/12/13 | 93/12/13 | 94/1/3 |
| 88 | 4.9 | احداث پياده رو | 20d | 2015-03-14 A | 2015-04-02 A | 87FS-10d | 100% | 2014-04-11 | 2014-04-30 | 20d | 93/1/22 | 93/2/10 | 93/12/23 | 93/12/23 | 94/1/13 |
| 89 | 4.10.5 | **اتصال و بهره برداری معارضات** | 343d | 2014-03-20 A | 2015-02-25 A |  | 100% | 2014-03-21 | 2014-04-19 | 30d | 93/1/1 | 93/1/30 | 92/12/29 | 92/12/29 | 93/12/6 |
| 90 | 4.10.5.1 | اتصال و بهره برداری خطوط جدید لوله های گازرسانی | 5d | 2014-09-17 A | 2014-09-21 A | 28 | 100% | 2014-04-15 | 2014-04-19 | 5d | 93/1/26 | 93/1/30 | 93/6/26 | 93/6/26 | 93/6/30 |
| 91 | 4.10.5.2 | اتصال و بهره برداری خطوط جدید لوله های آب و فاضلاب | 5d | 2014-06-19 A | 2014-06-23 A | 29 | 100% | 2014-04-15 | 2014-04-19 | 5d | 93/1/26 | 93/1/30 | 93/3/29 | 93/3/29 | 93/4/2 |
| 92 | 4.10.5.3 | اتصال و بهره برداری خطوط جدید برق | 5d | 2015-02-21 A | 2015-02-25 A | 30 | 100% | 2014-03-21 | 2014-03-25 | 5d | 93/1/1 | 93/1/5 | 93/12/2 | 93/12/2 | 93/12/6 |
| 93 | 4.10.5.4 | اتصال و بهره برداری خطوط جدید لوله های انتقال آب | 5d | 2014-12-30 A | 2015-01-03 A | 31 | 100% | 2014-03-21 | 2014-03-25 | 5d | 93/1/1 | 93/1/5 | 93/10/9 | 93/10/9 | 93/10/13 |
| 94 | 4.10.5.5 | نصب تابلوهای راهنمایی و رانندگی جدید | 5d | 2014-03-20 A | 2014-03-24 A | 32 | 100% | 2014-03-21 | 2014-03-25 | 5d | 93/1/1 | 93/1/5 | 92/12/29 | 92/12/29 | 93/1/4 |
| 95 | 4.10.5.6 | اتصال و بهره برداری کانالهای آبهای سطحی و زیر زمینی جدید | 5d | 2014-04-14 A | 2014-04-18 A | 33 | 100% | 2014-04-15 | 2014-04-19 | 5d | 93/1/26 | 93/1/30 | 93/1/25 | 93/1/25 | 93/1/29 |
| 96 | 4.10.5.7 | اتصال و بهره برداری از مسیر جدید کابل های مخابرات | 5d | 2014-08-01 A | 2014-08-05 A | 35 | 100% | 2014-03-22 | 2014-03-26 | 5d | 93/1/2 | 93/1/6 | 93/5/10 | 93/5/10 | 93/5/14 |
| 97 | 4.10 | **احداث مسیر سواره رو در قسمت شرقی محور جنوب به شمال** | 15d | 2015-02-26 A | 2015-03-12 A |  | 100% | 2014-04-20 | 2014-05-04 | 15d | 93/1/31 | 93/2/14 | 93/12/7 | 93/12/7 | 93/12/21 |
| 98 | 4.10 | زیر سازی | 10d | 2015-02-26 A | 2015-03-07 A | 28, 29, 33, 90, 91, 92, 93, 95 | 100% | 2014-04-20 | 2014-04-29 | 10d | 93/1/31 | 93/2/9 | 93/12/7 | 93/12/7 | 93/12/16 |
| 99 | 4.10 | روسازی | 10d | 2015-03-03 A | 2015-03-12 A | 98FS-5d | 100% | 2014-04-25 | 2014-05-04 | 10d | 93/2/5 | 93/2/14 | 93/12/12 | 93/12/12 | 93/12/21 |

| ID | WBS | Task | Duration | Start | Finish | Predecessors | Complete | Baseline start | Baseline finish | Baseline duration | Constraint | Text10 | Text11 | Text27 | Text29 | Text30 |
| --- | --- | --- | --- | --- | --- | --- | --- | --- | --- | --- | --- | --- | --- | --- | --- | --- |
| 100 | 4.12 | **برچيدن کارگاه موقت** | 2d | 2015-04-03 A | 2015-04-04 A |  | 100% | 2014-05-05 | 2014-05-06 | 2d |  | 93/2/15 | 93/2/16 | 94/1/14 | 94/1/14 | 94/1/15 |
| 101 | 4.12 | برچيدن کارگاه ضلع شرقی رمپ ورودی طبق انحراف ترافیک مرحله اول | 2d | 2015-04-03 A | 2015-04-04 A | 78, 83, 88, 99 | 100% | 2014-05-05 | 2014-05-06 | 2d |  | 93/2/15 | 93/2/16 | 94/1/14 | 94/1/14 | 94/1/15 |
| 102 | 5 | **مرحله دوم عمليات اجرايي** | 368d | 2014-05-10 A | 2015-05-12 A |  | 100% | 2014-05-10 | 2014-06-19 | 41d |  | 93/2/20 | 93/3/29 | 93/2/20 | 93/2/20 | 94/2/22 |
| 103 | 5.1 | **اجراي شمعهاي ضلع غربي رمپ ورودي** | 38d | 2014-05-10 A | 2014-06-16 A |  | 100% | 2014-05-10 | 2014-05-27 | 18d |  | 93/2/20 | 93/3/6 | 93/2/20 | 93/2/20 | 93/3/26 |
| 104 | 5.1.1 | حفاری شمع ها | 33d | 2014-05-10 A | 2014-06-11 A | 9, 90, 91, 92, 93, 94, 95 | 100% | 2014-05-10 | 2014-05-24 | 15d |  | 93/2/20 | 93/3/3 | 93/2/20 | 93/2/20 | 93/3/21 |
| 105 | 5.1.1 | آرماتور بندی شمع | 29d | 2014-05-10 A | 2014-06-07 A | 9 | 100% | 2014-05-10 | 2014-05-22 | 13d |  | 93/2/20 | 93/3/1 | 93/2/20 | 93/2/20 | 93/3/17 |
| 106 | 5.1.2 | کیج گذاری | 25d | 2014-05-22 A | 2014-06-15 A | 105FS-3d, 104FS-3d | 100% | 2014-05-22 | 2014-05-26 | 5d |  | 93/3/1 | 93/3/5 | 93/3/1 | 93/3/1 | 93/3/25 |
| 107 | 5.1.2 | بتن ریزی شمع ها | 25d | 2014-05-23 A | 2014-06-16 A | 106FS-4d | 100% | 2014-05-23 | 2014-05-27 | 5d |  | 93/3/2 | 93/3/6 | 93/3/2 | 93/3/2 | 93/3/26 |
| 108 | 5.2 | **اجراي تير همبند محور غربي رمپ ورودي** | 12d | 2014-06-17 A | 2014-06-28 A |  | 100% | 2014-05-28 | 2014-06-08 | 12d |  | 93/3/7 | 93/3/18 | 93/3/27 | 93/3/27 | 93/4/7 |
| 109 | 5.2 | آرماتور بندي | 5d | 2014-06-17 A | 2014-06-21 A | 107 | 100% | 2014-05-28 | 2014-06-01 | 5d |  | 93/3/7 | 93/3/11 | 93/3/27 | 93/3/27 | 93/3/31 |
| 110 | 5.2 | قالب بندي | 5d | 2014-06-22 A | 2014-06-26 A | 109 | 100% | 2014-06-02 | 2014-06-06 | 5d |  | 93/3/12 | 93/3/16 | 93/4/1 | 93/4/1 | 93/4/5 |
| 111 | 5.2 | بتن ريزي | 2d | 2014-06-27 A | 2014-06-28 A | 110 | 100% | 2014-06-07 | 2014-06-08 | 2d |  | 93/3/17 | 93/3/18 | 93/4/6 | 93/4/6 | 93/4/7 |
| 112 | 5.3 | **اجراي فونداسيون و ديوارهاي حائل ضلع غربي رمپ ورودي** | 33d | 2015-04-08 A | 2015-05-10 A |  | 100% | 2014-05-10 | 2014-06-11 | 33d |  | 93/2/20 | 93/3/21 | 94/1/19 | 94/1/19 | 94/2/20 |
| 113 | 5.3 | خاکبرداري محل ديوار و فونداسيون | 5d | 2015-04-08 A | 2015-04-12 A | 9, 31, 30, 33 | 100% | 2014-05-10 | 2014-05-14 | 5d | start no earlier than 2014-05-10 | 93/2/20 | 93/2/24 | 94/1/19 | 94/1/19 | 94/1/23 |
| 114 | 5.3 | اجراي بتن مگر | 2d | 2015-04-13 A | 2015-04-14 A | 113 | 100% | 2014-05-15 | 2014-05-16 | 2d | finish no earlier than 2014-05-16 | 93/2/25 | 93/2/26 | 94/1/24 | 94/1/24 | 94/1/25 |
| 115 | 5.3 | آرماتوربندي فونداسيون | 5d | 2015-04-15 A | 2015-04-19 A | 114 | 100% | 2014-05-17 | 2014-05-21 | 5d | finish no earlier than 2014-05-21 | 93/2/27 | 93/2/31 | 94/1/26 | 94/1/26 | 94/1/30 |
| 116 | 5.3 | قالب بندي فونداسيون | 5d | 2015-04-20 A | 2015-04-24 A | 115 | 100% | 2014-05-22 | 2014-05-26 | 5d | finish no earlier than 2014-05-26 | 93/3/1 | 93/3/5 | 94/1/31 | 94/1/31 | 94/2/4 |
| 117 | 5.3 | بتن ريزي فونداسيون | 2d | 2015-04-25 A | 2015-04-26 A | 116 | 100% | 2014-05-27 | 2014-05-28 | 2d | finish no earlier than 2014-05-28 | 93/3/6 | 93/3/7 | 94/2/5 | 94/2/5 | 94/2/6 |
| 118 | 5.3 | آرماتوربندي ديوار حائل | 5d | 2015-04-27 A | 2015-05-01 A | 117 | 100% | 2014-05-29 | 2014-06-02 | 5d | finish no earlier than 2014-06-02 | 93/3/8 | 93/3/12 | 94/2/7 | 94/2/7 | 94/2/11 |
| 119 | 5.3 | قالب بندي ديوار حائل | 5d | 2015-05-02 A | 2015-05-06 A | 118 | 100% | 2014-06-03 | 2014-06-07 | 5d | finish no earlier than 2014-06-07 | 93/3/13 | 93/3/17 | 94/2/12 | 94/2/12 | 94/2/16 |
| 120 | 5.3 | بتن ريزي ديوار حائل | 2d | 2015-05-07 A | 2015-05-08 A | 119 | 100% | 2014-06-08 | 2014-06-09 | 2d | finish no earlier than 2014-06-09 | 93/3/18 | 93/3/19 | 94/2/17 | 94/2/17 | 94/2/18 |
| 121 | 5.3 | اجراي درناژ پشت ديوار | 2d | 2015-05-09 A | 2015-05-10 A | 120 | 100% | 2014-06-10 | 2014-06-11 | 2d | finish no earlier than 2014-06-11 | 93/3/20 | 93/3/21 | 94/2/19 | 94/2/19 | 94/2/20 |
| 122 | 5.4 | **اجراي شمع هاي ضلع شمالی پل** | 86d | 2014-05-23 A | 2014-08-16 A |  | 100% | 2014-05-23 | 2014-06-17 | 26d |  | 93/3/2 | 93/3/27 | 93/3/2 | 93/3/2 | 93/5/25 |
| 123 | 5.4.1 | حفاری شمع ها طبق پلان انحراف | 70d | 2014-05-25 A | 2014-08-02 A | 104, 90, 91, 92, 93, 94, 95, 96 | 100% | 2014-05-25 | 2014-06-13 | 20d |  | 93/3/4 | 93/3/23 | 93/3/4 | 93/3/4 | 93/5/11 |
| 124 | 5.4.1 | آرماتور بندی شمع | 55d | 2014-05-23 A | 2014-07-16 A | 9, 105 | 100% | 2014-05-23 | 2014-06-06 | 15d |  | 93/3/2 | 93/3/16 | 93/3/2 | 93/3/2 | 93/4/25 |
| 125 | 5.4.2 | کیج گذاری | 60d | 2014-06-06 A | 2014-08-04 A | 124FS-8d, 123FS-8d | 100% | 2014-06-06 | 2014-06-15 | 10d |  | 93/3/16 | 93/3/25 | 93/3/16 | 93/3/16 | 93/5/13 |
| 126 | 5.4.2 | بتن ریزی شمع ها | 70d | 2014-06-08 A | 2014-08-16 A | 125FS-8d | 100% | 2014-06-08 | 2014-06-17 | 10d |  | 93/3/18 | 93/3/27 | 93/3/18 | 93/3/18 | 93/5/25 |

| ID | WBS | Task | Duration | Start | Finish | Predecessors | Complete | Baseline start | Baseline finish | Baseline duration | Text10 | Text11 | Text27 | Text29 | Text30 |
| --- | --- | --- | --- | --- | --- | --- | --- | --- | --- | --- | --- | --- | --- | --- | --- |
| 127 | 5.5 | **برچیدن کارگاه موقت** | 2d | 2015-05-11 A | 2015-05-12 A |  | 100% | 2014-06-18 | 2014-06-19 | 2d | 93/3/28 | 93/3/29 | 94/2/21 | 94/2/21 | 94/2/22 |
| 128 | 5.5.1 | برچیدن کارگاه مرحله دوم | 2d | 2015-05-11 A | 2015-05-12 A | 126, 121, 111, 107 | 100% | 2014-06-18 | 2014-06-19 | 2d | 93/3/28 | 93/3/29 | 94/2/21 | 94/2/21 | 94/2/22 |
| 129 | 6 | **مرحله سوم عملیات اجرایی** | 117d | 2014-06-23 A | 2014-10-17 A |  | 100% | 2014-06-23 | 2014-08-12 | 51d | 93/4/2 | 93/5/21 | 93/4/2 | 93/4/2 | 93/7/25 |
| 130 | 6.1 | **اجرای شمع های ضلع جنوبی پل** | 90d | 2014-06-23 A | 2014-09-20 A |  | 100% | 2014-06-23 | 2014-07-16 | 24d | 93/4/2 | 93/4/25 | 93/4/2 | 93/4/2 | 93/6/29 |
| 131 | 6.1.1 | حفاری شمع ها طبق پلان انحراف | 80d | 2014-06-23 A | 2014-09-10 A | 123, 10, 90, 91, 92, 93, 94, 95, 96 | 100% | 2014-06-23 | 2014-07-12 | 20d | 93/4/2 | 93/4/21 | 93/4/2 | 93/4/2 | 93/6/19 |
| 132 | 6.1.2 | آرماتور بندی شمع | 65d | 2014-06-23 A | 2014-08-26 A | 10, 124 | 100% | 2014-06-23 | 2014-07-07 | 15d | 93/4/2 | 93/4/16 | 93/4/2 | 93/4/2 | 93/6/4 |
| 133 | 6.1.3 | کیج گذاری | 76d | 2014-07-05 A | 2014-09-18 A | 132FS-8d, 131FS-8d | 100% | 2014-07-05 | 2014-07-14 | 10d | 93/4/14 | 93/4/23 | 93/4/14 | 93/4/14 | 93/6/27 |
| 134 | 6.1.4 | بتن ریزی شمع ها | 76d | 2014-07-07 A | 2014-09-20 A | 133FS-8d | 100% | 2014-07-07 | 2014-07-16 | 10d | 93/4/16 | 93/4/25 | 93/4/16 | 93/4/16 | 93/6/29 |
| 135 | 6.2 | **اجرای تابلیه و دال اپروچ در مسیر شمال به جنوب** | 25d | 2014-09-21 A | 2014-10-15 A |  | 100% | 2014-07-17 | 2014-08-10 | 25d | 93/4/26 | 93/5/19 | 93/6/30 | 93/6/30 | 93/7/23 |
| 136 | 6.2.1 | خاکبرداری | 5d | 2014-09-21 A | 2014-09-25 A | 134, 126 | 100% | 2014-07-17 | 2014-07-21 | 5d | 93/4/26 | 93/4/30 | 93/6/30 | 93/6/30 | 93/7/3 |
| 137 | 6.2.2 | رگلاژ کف | 2d | 2014-09-26 A | 2014-09-27 A | 136 | 100% | 2014-07-22 | 2014-07-23 | 2d | 93/4/31 | 93/5/1 | 93/7/4 | 93/7/4 | 93/7/5 |
| 138 | 6.2.3 | قالب بندی تیرهمبند و تابلیه و دال اپروچ | 12d | 2014-09-28 A | 2014-10-09 A | 137 | 100% | 2014-07-24 | 2014-08-04 | 12d | 93/5/2 | 93/5/13 | 93/7/6 | 93/7/6 | 93/7/17 |
| 139 | 6.2.4 | آرماتوربندی تیرهمبند و تابلیه و دال اپروچ | 12d | 2014-09-28 A | 2014-10-09 A | 138FS-12d | 100% | 2014-07-24 | 2014-08-04 | 12d | 93/5/2 | 93/5/13 | 93/7/6 | 93/7/6 | 93/7/17 |
| 140 | 6.2.5 | بتن ریزی تیرهمبند و تابلیه و دال اپروچ | 6d | 2014-10-10 A | 2014-10-15 A | 139 | 100% | 2014-08-05 | 2014-08-10 | 6d | 93/5/14 | 93/5/19 | 93/7/18 | 93/7/18 | 93/7/23 |
| 141 | 6.3 | **برچیدن کارگاه موقت** | 2d | 2014-10-16 A | 2014-10-17 A |  | 100% | 2014-08-11 | 2014-08-12 | 2d | 93/5/20 | 93/5/21 | 93/7/24 | 93/7/24 | 93/7/25 |
| 142 | 6.3.1 | برچیدن کارگاه موقت مرحله سوم | 2d | 2014-10-16 A | 2014-10-17 A | 140, 134 | 100% | 2014-08-11 | 2014-08-12 | 2d | 93/5/20 | 93/5/21 | 93/7/24 | 93/7/24 | 93/7/25 |
| 143 | 7 | **مرحله چهارم عملیات اجرایی** | 237d | 2014-08-16 A | 2015-04-09 A |  | 100% | 2014-08-16 | 2014-09-27 | 43d | 93/5/25 | 93/7/5 | 93/5/25 | 93/5/25 | 94/1/20 |
| 144 | 7.1 | **اجرای شمع های ضلع شمالی رمپ خروجی** | 73d | 2014-08-16 A | 2014-10-27 A |  | 100% | 2014-08-16 | 2014-09-04 | 20d | 93/5/25 | 93/6/13 | 93/5/25 | 93/5/25 | 93/8/5 |
| 145 | 7.1.1 | حفاری شمع ها طبق پلان انحراف | 68d | 2014-08-16 A | 2014-10-22 A | 11, 8, 19, 20, 21, 23 | 100% | 2014-08-16 | 2014-09-02 | 18d | 93/5/25 | 93/6/11 | 93/5/25 | 93/5/25 | 93/7/30 |
| 146 | 7.1.2 | آرماتور بندی شمع | 57d | 2014-08-16 A | 2014-10-11 A | 11 | 100% | 2014-08-16 | 2014-08-30 | 15d | 93/5/25 | 93/6/8 | 93/5/25 | 93/5/25 | 93/7/19 |
| 147 | 7.1.3 | کیج گذاری | 63d | 2014-08-25 A | 2014-10-26 A | 146FS-9d, 145FS-9d | 100% | 2014-08-25 | 2014-09-03 | 10d | 93/6/3 | 93/6/12 | 93/6/3 | 93/6/3 | 93/8/4 |
| 148 | 7.1.4 | بتن ریزی شمع ها | 63d | 2014-08-26 A | 2014-10-27 A | 147FS-9d | 100% | 2014-08-26 | 2014-09-04 | 10d | 93/6/4 | 93/6/13 | 93/6/4 | 93/6/4 | 93/8/5 |
| 149 | 7.2 | **اجرای تیرهای همبند ضلع شمالی رمپ خروجی** | 11d | 2014-10-28 A | 2014-11-07 A |  | 100% | 2014-09-05 | 2014-09-15 | 11d | 93/6/14 | 93/6/24 | 93/8/6 | 93/8/6 | 93/8/16 |
| 150 | 7.2.1 | آرماتور بندي | 5d | 2014-10-28 A | 2014-11-01 A | 148 | 100% | 2014-09-05 | 2014-09-09 | 5d | 93/6/14 | 93/6/18 | 93/8/6 | 93/8/6 | 93/8/10 |
| 151 | 7.2.2 | قالب بندي | 5d | 2014-11-01 A | 2014-11-05 A | 150FS-1d | 100% | 2014-09-09 | 2014-09-13 | 5d | 93/6/18 | 93/6/22 | 93/8/10 | 93/8/10 | 93/8/14 |
| 152 | 7.2.3 | بتن ريزي | 2d | 2014-11-06 A | 2014-11-07 A | 151 | 100% | 2014-09-14 | 2014-09-15 | 2d | 93/6/23 | 93/6/24 | 93/8/15 | 93/8/15 | 93/8/16 |

| ID | WBS | Task | Duration | Start | Finish | Predecessors | Complete | Baseline start | Baseline finish | Baseline duration | Text10 | Text11 | Text27 | Text29 | Text30 |
| --- | --- | --- | --- | --- | --- | --- | --- | --- | --- | --- | --- | --- | --- | --- | --- |
| 153 | 7.3 | **تکمیل شمع های محور شمالی پل** | 46d | 2014-10-21 A | 2014-12-05 A |  | 100% | 2014-08-16 | 2014-08-29 | 14d | 93/5/25 | 93/6/7 | 93/7/29 | 93/7/29 | 93/9/14 |
| 154 | 7.3.1 | حفاری شمع ها | 39d | 2014-10-21 A | 2014-11-28 A | 131, 11 | 100% | 2014-08-16 | 2014-08-25 | 10d | 93/5/25 | 93/6/3 | 93/7/29 | 93/7/29 | 93/9/7 |
| 155 | 7.3.2 | آرماتوربندی شمع | 38d | 2014-10-21 A | 2014-11-27 A | 11 | 100% | 2014-08-16 | 2014-08-25 | 10d | 93/5/25 | 93/6/3 | 93/7/29 | 93/7/29 | 93/9/6 |
| 156 | 7.3.3 | کیج گذاری | 42d | 2014-10-23 A | 2014-12-03 A | 155FS-8d, 154FS-8d | 100% | 2014-08-18 | 2014-08-27 | 10d | 93/5/27 | 93/6/5 | 93/8/1 | 93/8/1 | 93/9/12 |
| 157 | 7.3.4 | بتن ریزی شمع ها | 42d | 2014-10-25 A | 2014-12-05 A | 156FS-8d | 100% | 2014-08-20 | 2014-08-29 | 10d | 93/5/29 | 93/6/7 | 93/8/3 | 93/8/3 | 93/9/14 |
| 158 | 7.4 | **تکمیل تابلیه و دال اپروچ** | 17d | 2014-12-06 A | 2014-12-22 A |  | 100% | 2014-08-30 | 2014-09-15 | 17d | 93/6/8 | 93/6/24 | 93/9/15 | 93/9/15 | 93/10/1 |
| 159 | 7.4.1 | خاکبرداری | 5d | 2014-12-06 A | 2014-12-10 A | 126, 157 | 100% | 2014-08-30 | 2014-09-03 | 5d | 93/6/8 | 93/6/12 | 93/9/15 | 93/9/15 | 93/9/19 |
| 160 | 7.4.2 | رگلاژ کف | 2d | 2014-12-09 A | 2014-12-10 A | 159FS-2d | 100% | 2014-09-02 | 2014-09-03 | 2d | 93/6/11 | 93/6/12 | 93/9/18 | 93/9/18 | 93/9/19 |
| 161 | 7.4.3 | قالب بندی تیرهمبند و تابلیه و دال اپروچ | 12d | 2014-12-09 A | 2014-12-20 A | 160FS-2d | 100% | 2014-09-02 | 2014-09-13 | 12d | 93/6/11 | 93/6/22 | 93/9/18 | 93/9/18 | 93/9/29 |
| 162 | 7.4.4 | آرماتوربندی تیرهمبند و تابلیه و دال اپروچ | 12d | 2014-12-09 A | 2014-12-20 A | 161FS-12d | 100% | 2014-09-02 | 2014-09-13 | 12d | 93/6/11 | 93/6/22 | 93/9/18 | 93/9/18 | 93/9/29 |
| 163 | 7.4.5 | بتن ریزی تیرهمبند و تابلیه و دال اپروچ | 6d | 2014-12-17 A | 2014-12-22 A | 162FS-4d | 100% | 2014-09-10 | 2014-09-15 | 6d | 93/6/19 | 93/6/24 | 93/9/26 | 93/9/26 | 93/10/1 |
| 164 | 7.5 | **اجرای پیاده رو و جداول قسمت جنوبی محور غربی شرقی** | 41d | 2015-02-26 A | 2015-04-07 A |  | 100% | 2014-08-16 | 2014-09-25 | 41d | 93/5/25 | 93/7/3 | 93/12/7 | 93/12/7 | 94/1/18 |
| 165 | 7.5.1 | تخریب جداول قدیمی | 15d | 2015-02-26 A | 2015-03-12 A | 11, 93, 92 | 100% | 2014-08-16 | 2014-08-25 | 10d | 93/5/25 | 93/6/3 | 93/12/7 | 93/12/7 | 93/12/21 |
| 166 | 7.5.2 | تخریب پیاده رو قدیمی | 15d | 2015-02-27 A | 2015-03-13 A | 165FS-9d | 100% | 2014-08-17 | 2014-08-26 | 10d | 93/5/26 | 93/6/4 | 93/12/8 | 93/12/8 | 93/12/22 |
| 167 | 7.5.3 | احداث جداول | 15d | 2015-03-09 A | 2015-03-23 A | 166 | 100% | 2014-08-27 | 2014-09-05 | 10d | 93/6/5 | 93/6/14 | 93/12/18 | 93/12/18 | 94/1/3 |
| 168 | 7.5.4 | احداث پیاده رو | 25d | 2015-03-14 A | 2015-04-07 A | 167FS-5d, 163, 152 | 100% | 2014-09-16 | 2014-09-25 | 10d | 93/6/25 | 93/7/3 | 93/12/23 | 93/12/23 | 94/1/18 |
| 169 | 7.6 | **اجرای پیاده رو و جداول قسمت غربی محور شمال به جنوب** | 41d | 2015-02-26 A | 2015-04-07 A |  | 100% | 2014-08-16 | 2014-09-25 | 41d | 93/5/25 | 93/7/3 | 93/12/7 | 93/12/7 | 94/1/18 |
| 170 | 7.6.1 | تخریب جداول قدیمی | 15d | 2015-02-26 A | 2015-03-12 A | 11, 93, 92 | 100% | 2014-08-16 | 2014-08-25 | 10d | 93/5/25 | 93/6/3 | 93/12/7 | 93/12/7 | 93/12/21 |
| 171 | 7.6.2 | تخریب پیاده رو قدیمی | 15d | 2015-02-27 A | 2015-03-13 A | 170FS-9d | 100% | 2014-08-17 | 2014-08-26 | 10d | 93/5/26 | 93/6/4 | 93/12/8 | 93/12/8 | 93/12/22 |
| 172 | 7.6.3 | احداث جداول | 15d | 2015-03-09 A | 2015-03-23 A | 171 | 100% | 2014-08-27 | 2014-09-05 | 10d | 93/6/5 | 93/6/14 | 93/12/18 | 93/12/18 | 94/1/3 |
| 173 | 7.6.4 | احداث پیاده رو | 25d | 2015-03-14 A | 2015-04-07 A | 172FS-5d, 163, 152 | 100% | 2014-09-16 | 2014-09-25 | 10d | 93/6/25 | 93/7/3 | 93/12/23 | 93/12/23 | 94/1/18 |
| 174 | 7.7 | **برچیدن کارگاه موقت** | 2d | 2015-04-08 A | 2015-04-09 A |  | 100% | 2014-09-26 | 2014-09-27 | 2d | 93/7/4 | 93/7/5 | 94/1/19 | 94/1/19 | 94/1/20 |
| 175 | 7.7.1 | برچیدن کارگاه موقت مرحله چهارم | 2d | 2015-04-08 A | 2015-04-09 A | 173, 168, 163, 157 | 100% | 2014-09-26 | 2014-09-27 | 2d | 93/7/4 | 93/7/5 | 94/1/19 | 94/1/19 | 94/1/20 |
| 176 | 8 | **مرحله پنجم عملیات اجرایی** | 329d | 2014-10-11 A | 2015-09-04 A |  | 100% | 2014-09-14 | 2014-11-12 | 60d | 93/6/23 | 93/8/21 | 94/1/24 | 93/7/19 | 94/6/13 |
| 177 | 8.1 | **خاکبرداری** | 20d | 2015-04-13 A | 2015-05-02 A |  | 100% | 2014-10-01 | 2014-10-20 | 20d | 93/7/9 | 93/7/28 | 94/1/24 | 94/1/24 | 94/2/12 |
| 178 | 8.1.1 | خاکبرداری شیب راه رمپ ورودی | 5d | 2015-04-13 A | 2015-04-17 A | 163, 12 | 100% | 2014-10-01 | 2014-10-05 | 5d | 93/7/9 | 93/7/13 | 94/1/24 | 94/1/24 | 94/1/28 |
| 179 | 8.1.2 | خاکبرداری شیب راه رمپ خروجی | 5d | 2015-04-13 A | 2015-04-17 A | 163, 12 | 100% | 2014-10-01 | 2014-10-05 | 5d | 93/7/9 | 93/7/13 | 94/1/24 | 94/1/24 | 94/1/28 |
| 180 | 8.1.3 | خاکبرداری رمپ ورودی | 5d | 2015-04-18 A | 2015-04-22 A | 178 | 100% | 2014-10-06 | 2014-10-10 | 5d | 93/7/14 | 93/7/18 | 94/1/29 | 94/1/29 | 94/2/2 |
| 181 | 8.1.4 | خاکبرداری رمپ خروجی | 5d | 2015-04-18 A | 2015-04-22 A | 179 | 100% | 2014-10-06 | 2014-10-10 | 5d | 93/7/14 | 93/7/18 | 94/1/29 | 94/1/29 | 94/2/2 |
| 182 | 8.1.5 | خاکبرداری زیر گذر از سمت رمپ ورودی | 10d | 2015-04-23 A | 2015-05-02 A | 180 | 100% | 2014-10-11 | 2014-10-20 | 10d | 93/7/19 | 93/7/28 | 94/2/3 | 94/2/3 | 94/2/12 |
| 183 | 8.1.6 | خاکبرداری زیر گذر از سمت رمپ خروجی | 10d | 2015-04-23 A | 2015-05-02 A | 181 | 100% | 2014-10-11 | 2014-10-20 | 10d | 93/7/19 | 93/7/28 | 94/2/3 | 94/2/3 | 94/2/12 |

| ID | WBS | Task | Duration | Start | Finish | Predecessors | Complete | Baseline start | Baseline finish | Baseline duration | Text10 | Text11 | Text27 | Text29 | Text30 |
| --- | --- | --- | --- | --- | --- | --- | --- | --- | --- | --- | --- | --- | --- | --- | --- |
| 184 | 8.2 | **اجرای دیوار نما** | 15d | 2014-10-11 A | 2014-10-25 A |  | 100% | 2014-10-11 | 2014-10-25 | 15d | 93/7/19 | 93/8/3 | 94/2/3 | 93/7/19 | 93/8/3 |
| 185 | 8.2.1 | اجرای دیوار نمای رمپ ورودی | 12d | 2014-10-11 A | 2014-10-22 A | 180 | 100% | 2014-10-11 | 2014-10-22 | 12d | 93/7/19 | 93/7/30 | 94/2/3 | 93/7/19 | 93/7/30 |
| 186 | 8.2.2 | اجرای دیوار نمای رمپ خروجی | 12d | 2014-10-11 A | 2014-10-22 A | 181 | 100% | 2014-10-11 | 2014-10-22 | 12d | 93/7/19 | 93/7/30 | 94/2/3 | 93/7/19 | 93/7/30 |
| 187 | 8.2.3 | اجرای دیوار نمای زیر تابلیه | 15d | 2014-10-11 A | 2014-10-25 A | 182FS-10d, 183FS-10d | 100% | 2014-10-11 | 2014-10-25 | 15d | 93/7/19 | 93/8/3 | 94/2/3 | 93/7/19 | 93/8/3 |
| 188 | 8.3 | **اجرای گاردریل** | 20d | 2015-08-13 A | 2015-09-01 A |  | 100% | 2014-09-14 | 2014-10-03 | 20d | 93/6/23 | 93/7/11 | 94/5/22 | 94/5/22 | 94/6/10 |
| 189 | 8.3.1 | اجرای گاردریل رمپ ورودی | 15d | 2015-08-13 A | 2015-08-27 A | 73FS+94d, 121FS+94d, 44, 111 | 100% | 2014-09-14 | 2014-09-28 | 15d | 93/6/23 | 93/7/6 | 94/5/22 | 94/5/22 | 94/6/5 |
| 190 | 8.3.2 | اجرای گاردریل رمپ خروجی | 14d | 2015-08-19 A | 2015-09-01 A | 63FS+100d, 121FS+100d, 53 | 100% | 2014-09-20 | 2014-10-03 | 14d | 93/6/29 | 93/7/11 | 94/5/28 | 94/5/28 | 94/6/10 |
| 191 | 8.4 | **اجرای ابنیه** | 10d | 2015-05-03 A | 2015-05-12 A |  | 100% | 2014-10-21 | 2014-10-30 | 10d | 93/7/29 | 93/8/8 | 94/2/13 | 94/2/13 | 94/2/22 |
| 192 | 8.4.1 | اجرای ابنیه فنی زیر گذر | 10d | 2015-05-03 A | 2015-05-12 A | 182, 183 | 100% | 2014-10-21 | 2014-10-30 | 10d | 93/7/29 | 93/8/8 | 94/2/13 | 94/2/13 | 94/2/22 |
| 193 | 8.5 | **زیر سازی** | 10d | 2015-05-13 A | 2015-05-22 A |  | 100% | 2014-10-31 | 2014-11-09 | 10d | 93/8/9 | 93/8/18 | 94/2/23 | 94/2/23 | 94/3/1 |
| 194 | 8.5.1 | زیر سازی شیب راهه | 3d | 2015-05-13 A | 2015-05-15 A | 192 | 100% | 2014-10-31 | 2014-11-02 | 3d | 93/8/9 | 93/8/11 | 94/2/23 | 94/2/23 | 94/2/25 |
| 195 | 8.5.2 | زیر سازی رمپ ها | 5d | 2015-05-14 A | 2015-05-18 A | 194FS-2d | 100% | 2014-11-01 | 2014-11-05 | 5d | 93/8/10 | 93/8/14 | 94/2/24 | 94/2/24 | 94/2/28 |
| 196 | 8.5.3 | زیر سازی زیر گذر | 7d | 2015-05-16 A | 2015-05-22 A | 195FS-3d | 100% | 2014-11-03 | 2014-11-09 | 7d | 93/8/12 | 93/8/18 | 94/2/26 | 94/2/26 | 94/3/1 |
| 197 | 8.6 | **روسازی** | 5d | 2015-05-18 A | 2015-05-22 A |  | 100% | 2014-11-05 | 2014-11-09 | 5d | 93/8/14 | 93/8/18 | 94/2/28 | 94/2/28 | 94/3/1 |
| 198 | 8.6.1 | روسازی زیر گذر و رمپها و شیب راهه ها | 5d | 2015-05-18 A | 2015-05-22 A | 196FS-5d | 100% | 2014-11-05 | 2014-11-09 | 5d | 93/8/14 | 93/8/18 | 94/2/28 | 94/2/28 | 94/3/1 |
| 199 | 8.7 | **برچیدن کارگاه** | 3d | 2015-09-02 A | 2015-09-04 A |  | 100% | 2014-11-10 | 2014-11-12 | 3d | 93/8/19 | 93/8/21 | 94/6/11 | 94/6/11 | 94/6/13 |
| 200 | 8.7.1 | برچیدن کارگاه | 3d | 2015-09-02 A | 2015-09-04 A | 173, 101, 189, 190, 198, 168, 185, 186, 187 | 100% | 2014-11-10 | 2014-11-12 | 3d | 93/8/19 | 93/8/21 | 94/6/11 | 94/6/11 | 94/6/13 |
| 201 | 8.7.2 | تحویل پروژه و اتمام کار | 1d | 2015-09-04 A | 2015-09-04 A | 200 | 100% | 2014-11-12 | 2014-11-12 | 0d | 93/8/21 | 93/8/21 | 94/6/13 | 94/6/13 | 94/6/13 |
